# HPLGapProd10cpw07

Schedule from MS Project, 2006-12-05 to 2007-10-17.
CERN

## Calendars

- Standard: Mon-Fri 08:00-12:00, 13:00-17:00; Sat-Sun off.

## Schedule

| ID | Task | Duration | Start | Finish | Predecessors | Total slack | Free slack | Constraint |
| --- | --- | --- | --- | --- | --- | --- | --- | --- |
| 1 | RE-3 HPL delivered to Korea | 4d? | 2006-12-05 | 2006-12-08 |  | 119d | 0d | start no earlier than 2006-12-05 |
| 2 | Contingency HPL Delivery to Korea | 4.5d? | 2007-02-05 | 2007-02-09 |  | 8.5d | 4.5d | start no earlier than 2007-02-05 |
| 3 | Gap Prod RE-2/3 suppliment | 16d? | 2006-12-11 | 2007-01-01 | 1 | 119d | 17d |  |
| 4 | Delivery to PK | 7d? | 2007-01-25 | 2007-02-02 | 3 | 102d | 0d | start no earlier than 2007-01-25 |
| 5 | Prod. PK RE-2 ? | 20d? | 2007-02-05 | 2007-03-02 | 4 | 102d | 0d | start no earlier than 2007-01-03 |
| 6 | Delivery to CERN | 8d? | 2007-03-05 | 2007-03-14 | 5 | 102d | 0d | start no earlier than 2007-03-04 |
| 7 | Cosmic testing | 10d? | 2007-03-15 | 2007-03-28 | 6 | 102d | 0d |  |
| 8 | RE-2 Installation | 11d? | 2007-03-29 | 2007-04-12 | 7 | 102d | 0d |  |
| 9 | RE-2 Services | 20d? | 2007-04-13 | 2007-05-10 | 8 | 102d |  |  |
| 10 | RE3/2 Gap Prod. | 31d? | 2007-03-09 | 2007-04-20 | 2 | 0d |  | start no earlier than 2007-03-09 |
| 11 | Delivery to PK | 7d | 2007-04-23 | 2007-05-01 | 10 | 6d | 0d | start no earlier than 2007-03-24 |
| 12 | RE-3/2 Chamber Prod | 23d? | 2007-05-02 | 2007-06-01 | 11 | 22d | 0d | start no earlier than 2007-04-02 |
| 13 | Delivery to CERN | 7d? | 2007-06-04 | 2007-06-12 | 12 | 22d | 0d |  |
| 14 | Cosmic testing | 19d? | 2007-06-13 | 2007-07-09 | 13 | 22d | 0d |  |
| 15 | RE-3/2 Installation | 5d? | 2007-07-10 | 2007-07-16 | 14 | 67d |  |  |
| 16 | RE3/3 Gap Prod. | 31d? | 2007-04-23 | 2007-06-04 | 10 | 0d |  | start no earlier than 2007-03-31 |
| 17 | Delivery to PK | 10d? | 2007-06-05 | 2007-06-18 | 16 | 87d |  | start no earlier than 2007-04-25 |
| 18 | RE-3/3 Chamber Prod | 24d? | 2007-06-18 | 2007-07-19 | 11 | 17d | 0d | start no earlier than 2007-06-17 |
| 19 | Delivery to CERN | 7d? | 2007-07-20 | 2007-07-30 | 18 | 17d |  |  |
| 20 | Cosmic testing | 13d? | 2007-08-23 | 2007-09-10 | 19, 27 | 0d |  |  |
| 21 | RE-3/3 Installation | 5d? | 2007-09-11 | 2007-09-17 | 20 | 0d |  |  |
| 22 | RE-3 Services | 22d? | 2007-09-18 | 2007-10-17 | 21 | 0d |  |  |
| 23 | Indian Gap Prod. | 7d? | 2007-06-05 | 2007-06-13 | 16 | 0d |  | start no earlier than 2007-04-26 |
| 24 | Delivery to India | 10d? | 2007-06-14 | 2007-06-27 | 23 | 0d |  |  |
| 25 | Assemble in India | 20d? | 2007-06-28 | 2007-07-25 | 24 | 0d |  |  |
| 26 | Delivery to CERN | 10d? | 2007-07-26 | 2007-08-08 | 25 | 0d |  |  |
| 27 | Cosmic testing | 10d? | 2007-08-09 | 2007-08-22 | 26, 14 | 0d |  |  |
